# CablesRE3

Schedule from MS Project, 2006-09-25 to 2007-03-02.
CERN

## Calendars

- Standard: Mon-Fri 08:00-12:00, 13:00-17:00; Sat-Sun off.

## Schedule

| ID | WBS | Task | Duration | Start | Finish | Predecessors | Total slack | Free slack | Constraint |
| --- | --- | --- | --- | --- | --- | --- | --- | --- | --- |
| 2 | 1 | **RE+3** | 47d? | 2006-10-05 | 2006-12-08 |  | 15d |  |  |
| 3 | 1.1 | Hv | 11d? | 2006-10-05 | 2006-10-19 |  | 65d | 0d | start no earlier than 2006-10-05 |
| 4 | 1.2 | LV | 6.5d? | 2006-10-20 | 2006-10-30 | 3 | 65d | 0d |  |
| 5 | 1.3 | Temp. | 1.5d? | 2006-10-30 | 2006-10-31 | 4 | 65d | 0d |  |
| 6 | 1.4 | DCS | 3d? | 2006-11-01 | 2006-11-03 | 5 | 65d | 0d | start no earlier than 2006-10-30 |
| 7 | 1.5 | Signal | 32d? | 2006-10-26 | 2006-12-08 |  | 0d |  | start no earlier than 2006-10-26 |
| 9 | 2 | **RE-13** | 75d? | 2006-09-25 | 2007-01-05 |  | 40d |  |  |
| 10 | 2.1 | Hv | 1d? | 2006-09-25 | 2006-09-25 |  | 111d | 1d | start no earlier than 2006-09-25 |
| 11 | 2.2 | LV | 1d? | 2006-09-27 | 2006-09-27 | 10 | 110d | 0d | start no earlier than 2006-09-27 |
| 12 | 2.3 | DCS | 1d? | 2006-09-28 | 2006-09-28 | 11 | 110d | 1d |  |
| 13 | 2.4 | Temp. | 1d? | 2006-10-02 | 2006-10-02 | 12 | 109d |  | start no earlier than 2006-10-02 |
| 14 | 2.5 | Signal | 20d? | 2006-12-11 | 2007-01-05 | 7 | 0d |  | start no earlier than 2006-12-11 |
| 16 | 3 | **RE-2** | 90d? | 2006-10-02 | 2007-02-02 |  | 20d |  |  |
| 17 | 3.1 | Hv | 1d? | 2006-10-02 | 2006-10-02 |  | 106d | 0d | start no earlier than 2006-10-02 |
| 18 | 3.2 | LV | 1d? | 2006-10-03 | 2006-10-03 | 17 | 106d | 0d |  |
| 19 | 3.3 | DCS | 1d? | 2006-10-04 | 2006-10-04 | 18 | 106d | 0d |  |
| 20 | 3.4 | Temp. | 1d? | 2006-10-05 | 2006-10-05 | 19 | 106d |  |  |
| 21 | 3.5 | Signal | 20d? | 2007-01-08 | 2007-02-02 | 14 | 0d |  | start no earlier than 2007-01-08 |
| 23 | 4 | **RE-3** | 85d? | 2006-11-06 | 2007-03-02 |  | 0d |  |  |
| 24 | 4.1 | Hv | 10d? | 2006-11-06 | 2006-11-17 | 6 | 65d | 0d |  |
| 25 | 4.2 | LV | 5d? | 2006-11-20 | 2006-11-24 | 24 | 65d | 0d |  |
| 26 | 4.3 | DCS | 3d? | 2006-11-27 | 2006-11-29 | 25 | 65d | 0d |  |
| 27 | 4.4 | Temp. | 2d? | 2006-11-30 | 2006-12-01 | 26 | 65d |  |  |
| 28 | 4.5 | Signal | 20d? | 2007-02-05 | 2007-03-02 | 21 | 0d |  | start no earlier than 2007-02-05 |
