# CablesRE3

Schedule from MS Project, 2006-09-25 to 2007-06-29, A marks actual dates.
CERN

## Calendars

- Standard: Mon-Fri 08:00-12:00, 13:00-17:00; Sat-Sun off.

## Schedule

| ID | WBS | Task | Duration | Start | Finish | Predecessors | Complete | Total slack | Free slack | Constraint |
| --- | --- | --- | --- | --- | --- | --- | --- | --- | --- | --- |
| 2 | 1 | RE+3 Hv | 11d? | 2006-10-05 | 2006-10-19 |  |  | 150d | 0d | start no earlier than 2006-10-05 |
| 3 | 2 | LV | 6.5d? | 2006-10-20 | 2006-10-30 | 2 |  | 150d | 0d |  |
| 4 | 3 | Temp. | 1.5d? | 2006-10-30 | 2006-10-31 | 3 |  | 150d | 0d |  |
| 5 | 4 | DCS | 3d? | 2006-11-01 | 2006-11-03 | 4 |  | 150d | 0d | start no earlier than 2006-10-30 |
| 6 | 5 | Signal | 32d? | 2006-10-26 | 2006-12-08 |  |  | 145d |  | start no earlier than 2006-10-26 |
| 8 | 6 | RE-13 Hv | 1d? | 2006-09-25 | 2006-09-25 |  |  | 196d | 1d | start no earlier than 2006-09-25 |
| 9 | 7 | LV | 1d? | 2006-09-27 | 2006-09-27 | 8 |  | 195d | 0d | start no earlier than 2006-09-27 |
| 10 | 8 | DCS | 1d? | 2006-09-28 | 2006-09-28 | 9 |  | 195d | 1d |  |
| 11 | 9 | Temp. | 1d? | 2006-10-02 | 2006-10-02 | 10 |  | 194d |  | start no earlier than 2006-10-02 |
| 12 | 10 | Signal | 20d? | 2006-12-11 A | 2007-01-05 A | 6 | 100% |  |  | start no earlier than 2006-12-11 |
| 13 | 11 | Chamber Installtion | 8d? | 2007-01-31 | 2007-02-09 |  |  | 100d |  | start no earlier than 2007-01-31 |
| 15 | 12 | RE-2 HV | 1d? | 2006-11-06 | 2006-11-06 |  |  | 166d | 0d |  |
| 16 | 13 | RE-2 LV | 1d? | 2006-11-07 | 2006-11-07 | 15 |  | 166d | 0d |  |
| 17 | 14 | DCS | 1d? | 2006-11-08 | 2006-11-08 | 16 |  | 166d | 0d |  |
| 18 | 15 | Temp. | 1d? | 2006-11-09 | 2006-11-09 | 17 |  | 166d |  |  |
| 19 | 16 | Signal *2 | 15d? | 2007-01-07 A | 2007-01-26 A | 12 | 100% |  |  |  |
| 20 | 17 | Signal *3 | 10d? | 2007-02-12 | 2007-02-23 | 19 |  | 66d | 51d | start no earlier than 2007-02-12 |
| 21 | 18 | Chamber Installation | 10d? | 2007-03-05 | 2007-03-16 |  |  | 75d |  | start no earlier than 2007-03-05 |
| 23 | 19 | RE-3 Hv | 10d? | 2006-11-06 | 2006-11-17 | 5 |  | 150d | 0d |  |
| 24 | 20 | LV | 5d? | 2006-11-20 | 2006-11-24 | 23 |  | 150d | 0d |  |
| 25 | 21 | DCS | 3d? | 2006-11-27 | 2006-11-29 | 24 |  | 150d | 0d |  |
| 26 | 22 | Temp. | 2d? | 2006-11-30 | 2006-12-01 | 25 |  | 150d |  |  |
| 27 | 23 | Signal *2 | 12d? | 2007-05-08 | 2007-05-23 | 20 |  | 15d | 0d | start no earlier than 2007-05-08 |
| 28 | 24 | Signal *3 | 12d? | 2007-05-24 | 2007-06-08 | 27 |  | 15d |  |  |
| 29 | 25 | Chamber Installation | 15d? | 2007-06-11 | 2007-06-29 |  |  | 0d |  | start no earlier than 2007-06-10 |
